# aikataulu

Schedule from MS Project, 2004-09-17 to 2004-12-17, A marks actual dates.
University Of Jyväskylä

## Calendars

- Standard: Mon-Fri 08:00-12:00, 13:00-17:00; Sat-Sun off.

## Schedule

| ID | WBS | Task | Duration | Start | Finish | Complete | Remaining | Total slack | Constraint |
| --- | --- | --- | --- | --- | --- | --- | --- | --- | --- |
| 2 | 1 | **TARKEMPI AIKATAULU** | 55d? | 2004-10-04 A | 2004-12-17 | 51% | 26.89d? | 0d |  |
| 3 | 1.1 | **Tietokanta** | 40d? | 2004-10-04 A | 2004-11-26 | 53% | 18.68d? | 15d |  |
| 4 | 1.1.1 | **Kannan suunnittelu** | 15d? | 2004-10-04 A | 2004-10-22 | 93% | 1d? | 40d | start no earlier than 2004-10-04 |
| 5 | 1.1.1.1 | TARE:n kannan luonti | 10d? | 2004-10-18 A | 2004-10-29 | 90% | 1d? | 35d | start no earlier than 2004-10-18 |
| 6 | 1.1.1.2 | TARE:n Kannan integrointi DUOON(testijärjestelmä) | 10d? | 2004-11-15 | 2004-11-26 |  |  | 15d | start no earlier than 2004-11-15 |
| 7 | 1.1.1.3 | TATE:n tietojen siirron suunnittelu | 8.5d? | 2004-10-20 A | 2004-11-01 A | 100% |  |  | start no earlier than 2004-10-20 |
| 8 | 1.1.1.4 | TATE:n tietojen siirron ohjelman toteutus | 13d? | 2004-10-28 A | 2004-11-15 | 69% | 4d? | 24d | start no earlier than 2004-10-28 |
| 9 | 1.1.1.5 | TATE:n tietojen siirron ohjelman testaus | 11.5d? | 2004-11-04 | 2004-11-19 |  |  | 20.5d | start no earlier than 2004-11-04 |
| 10 | 1.1.1.6 | TATE:n tietojen siirto yhteiskantaan(testikanta) | 8d? | 2004-11-11 | 2004-11-22 |  |  | 19d | start no earlier than 2004-11-11 |
| 11 | 1.1.2 | **Käyttöliittymän suunnittelu** | 10d? | 2004-10-25 A | 2004-11-05 | 93% | 0.67d? | 30d |  |
| 12 | 1.1.2.1 | Käyttöliittymän suunnittelu | 10d? | 2004-10-25 A | 2004-11-05 | 90% | 1d? | 30d | start no earlier than 2004-10-25 |
| 13 | 1.1.2.2 | Käyttäjien haastattelu (käyttöliittymän suunnittelua) | 5d? | 2004-11-01 A | 2004-11-05 A | 100% |  |  | start no earlier than 2004-11-01 |
| 14 | 1.1.3 | **Käyttöliittymän toteutus** | 25d? | 2004-10-25 A | 2004-11-26 | 41% | 14.63d? | 15d |  |
| 15 | 1.1.3.1 | Käyttöliittymärungon toteutusta | 10d? | 2004-10-25 A | 2004-11-05 | 90% | 1d? | 30d | start no earlier than 2004-10-25 |
| 16 | 1.1.3.2 | Sisäänkirjautumisen toteutus | 2d? | 2004-11-02 A | 2004-11-03 A | 100% |  |  | start no earlier than 2004-11-02 |
| 17 | 1.1.3.3 | Raporttien toteutus | 5d? | 2004-11-22 | 2004-11-26 |  |  | 15d | start no earlier than 2004-11-22 |
| 18 | 1.1.3.4 | Käyttäjänhallinnan toteutus | 4d? | 2004-11-09 A | 2004-11-12 A | 100% |  |  | start no earlier than 2004-11-09 |
| 19 | 1.1.3.5 | Päätietolomakkeiden toteutus | 10d? | 2004-11-08 A | 2004-11-19 | 20% | 8d? | 20d | start no earlier than 2004-11-08 |
| 20 | 1.1.3.6 | Lisätietolomakkeiden toteutus | 10d? | 2004-11-15 | 2004-11-26 |  |  | 15d | start no earlier than 2004-11-15 |
| 21 | 1.1.4 | **Käyttöliittymän testaus** | 15d? | 2004-11-15 | 2004-12-03 |  |  | 10d |  |
| 22 | 1.1.4.1 | Käyttöliittymän testaus | 15d? | 2004-11-15 | 2004-12-03 |  |  | 10d | start no earlier than 2004-11-15 |
| 23 | 1.1.5 | **WWW** | 50d? | 2004-10-11 A | 2004-12-17 | 58% | 21.24d? | 0d |  |
| 24 | 1.1.5.1 | WWW kotisivut projektille | 6.5d? | 2004-10-11 A | 2004-10-19 A | 100% |  |  | start no earlier than 2004-10-11 |
| 25 | 1.1.5.2 | WWW-sivujen ylläpito | 50d? | 2004-10-11 A | 2004-12-17 | 52% | 24d? | 0d | start no earlier than 2004-10-11 |

| ID | WBS | Task | Duration | Start | Finish | Complete | Remaining | Total slack | Constraint |
| --- | --- | --- | --- | --- | --- | --- | --- | --- | --- |
| 30 | 1.2 | **DOKUMENTTIEN AIKATAULU** | 62d? | 2004-09-23 A | 2004-12-17 | 66% | 20.84d? | 0d |  |
| 31 | 1.2.1 | Aikataulun teko ja ylläpito | 60d? | 2004-09-27 A | 2004-12-17 | 57% | 26d? | 0d | start no earlier than 2004-09-27 |
| 32 | 1.2.2 | Lisenssien selvitys | 14d? | 2004-10-04 A | 2004-10-21 | 93% | 1d? | 41d | start no earlier than 2004-10-04 |
| 33 | 1.2.3 | Vaatimusmäärittelyn teko | 24.5d? | 2004-09-27 A | 2004-10-29 | 94% | 1.5d? | 35.5d | start no earlier than 2004-09-27 |
| 34 | 1.2.4 | Projektisuunnitelman teko | 24.5d? | 2004-09-27 A | 2004-10-29 | 94% | 1.5d? | 35.5d | start no earlier than 2004-09-27 |
| 35 | 1.2.5 | Sovellussuunnitelman teko | 8d? | 2004-10-27 A | 2004-11-05 | 38% | 5d? | 30d | start no earlier than 2004-10-27 |
| 36 | 1.2.6 | Testaussuunnitelman teko | 10d? | 2004-11-08 | 2004-11-19 |  |  | 20d | start no earlier than 2004-11-08 |
| 37 | 1.2.7 | Testausraportin teko | 5d? | 2004-11-29 | 2004-12-03 |  |  | 10d | start no earlier than 2004-11-29 |
| 38 | 1.2.8 | Sovellusraportin teko | 4d? | 2004-11-29 | 2004-12-02 |  |  | 11d | start no earlier than 2004-11-29 |
| 39 | 1.2.9 | Projektiraportin teko | 5d? | 2004-12-06 | 2004-12-10 |  |  | 5d | start no earlier than 2004-12-06 |
| 40 | 1.2.10 | Väliesittely 1:n pöytäkirja | 1d? | 2004-11-03 A | 2004-11-03 A | 100% |  |  | start no earlier than 2004-11-03 |
| 41 | 1.2.11 | Esityslista 1 | 1d? | 2004-09-23 A | 2004-09-23 A | 100% |  |  | start no earlier than 2004-09-23 |
| 42 | 1.2.12 | Esityslista 2 | 1d? | 2004-09-30 A | 2004-09-30 A | 100% |  |  | start no earlier than 2004-09-30 |
| 43 | 1.2.13 | Esityslista 3 | 1d? | 2004-10-07 A | 2004-10-07 A | 100% |  |  | start no earlier than 2004-10-07 |
| 44 | 1.2.14 | Esityslista 4 | 1d? | 2004-10-14 A | 2004-10-14 A | 100% |  |  | start no earlier than 2004-10-14 |
| 45 | 1.2.15 | Esityslista 5 | 1d? | 2004-10-21 A | 2004-10-21 A | 100% |  |  | start no earlier than 2004-10-21 |
| 46 | 1.2.16 | Esityslista 6 | 1d? | 2004-10-29 A | 2004-10-29 A | 100% |  |  | start no earlier than 2004-10-29 |
| 47 | 1.2.17 | Esityslista 7 | 1d? | 2004-11-05 A | 2004-11-05 A | 100% |  |  | start no earlier than 2004-11-05 |
| 48 | 1.2.18 | Esityslista 8 | 1d? | 2004-11-15 A | 2004-11-15 A | 100% |  |  | start no earlier than 2004-11-08 |
| 49 | 1.2.19 | Pöytäkirja 1 | 3d? | 2004-09-27 A | 2004-09-29 A | 100% |  |  | start no earlier than 2004-09-27 |
| 50 | 1.2.20 | Pöytäkirja 2 | 3d? | 2004-10-04 A | 2004-10-06 A | 100% |  |  | start no earlier than 2004-10-04 |
| 51 | 1.2.21 | Pöytäkirja 3 | 2.5d? | 2004-10-11 A | 2004-10-13 A | 100% |  |  | start no earlier than 2004-10-11 |
| 52 | 1.2.22 | Pöytäkirja 4 | 1d? | 2004-10-18 A | 2004-10-18 A | 100% |  |  | start no earlier than 2004-10-18 |
| 53 | 1.2.23 | Pöytäkirja 5 | 2d? | 2004-10-25 A | 2004-10-26 A | 100% |  |  | start no earlier than 2004-10-25 |
| 54 | 1.2.24 | Pöytäkirja 6 | 2d? | 2004-11-02 A | 2004-11-03 A | 100% |  |  | start no earlier than 2004-11-02 |
| 55 | 1.2.25 | Pöytäkirja 7 | 2d? | 2004-11-10 A | 2004-11-11 A | 100% |  |  | start no earlier than 2004-11-10 |
| 56 | 1.2.26 | Pöytäkirja 8 | 2d? | 2004-11-16 | 2004-11-17 |  |  | 22d | start no earlier than 2004-11-16 |

| ID | WBS | Task | Type | Duration | Start | Finish | Predecessors | Complete | Remaining | Total slack | Free slack | Constraint |
| --- | --- | --- | --- | --- | --- | --- | --- | --- | --- | --- | --- | --- |
| 59 | 1.3 | **YLEINEN AIKATAULU** |  | 66d? | 2004-09-17 A | 2004-12-17 |  | 70% | 20.05d? | 0d |  |  |
| 60 | 1.3.1 | **LUENNOT JA KOULUTUKSET** |  | 41d? | 2004-09-17 A | 2004-11-12 A |  | 100% |  |  |  |  |
| 61 | 1 | Aloitusluento |  | 4h | 2004-09-17 A | 2004-09-17 A |  | 100% |  |  |  |  |
| 62 | 1.3.1.2 | Luento: Projektin johtaminen ja hallinta |  | 4h? | 2004-10-01 A | 2004-10-01 A |  | 100% |  |  |  | start no earlier than 2004-10-01 |
| 63 | 1.3.1.3 | CVS ja Bugzilla luento ja asentelu |  | 4h | 2004-10-13 A | 2004-10-13 A |  | 100% |  |  |  | start no earlier than 2004-10-13 |
| 64 | 1.3.1.4 | Luento:Tekijänoikeus ja sopimukset |  | 2h | 2004-10-27 A | 2004-10-27 A |  | 100% |  |  |  | start no earlier than 2004-10-27 |
| 65 | 1.3.1.5 | Luento:käytettävyys |  | 1d? | 2004-11-12 A | 2004-11-12 A |  | 100% |  |  |  | start no earlier than 2004-11-12 |
| 68 | 2 | Ensimmäinen projektipalaveri | milestone | 0d | 2004-09-27 | 2004-09-27 |  |  |  | 60d |  | start no earlier than 2004-09-27 |
| 69 | 3 | Aiheeseen tutustuminen |  | 22d? | 2004-09-17 A | 2004-10-18 A |  | 100% |  |  |  |  |
| 70 | 4 | Projektisuunnittelu |  | 18d? | 2004-09-29 A | 2004-10-22 |  | 94% | 1d? | 40d |  | start no earlier than 2004-09-29 |
| 71 | 5 | Määrittely |  | 23d? | 2004-09-29 A | 2004-10-29 A |  | 100% |  |  |  | start no earlier than 2004-09-29 |
| 72 | 6 | Suunnittelu |  | 25d? | 2004-10-04 A | 2004-11-05 |  | 84% | 4d? | 30d |  | start no earlier than 2004-10-04 |
| 73 | 7 | Työkaluihin tutustuminen |  | 27d? | 2004-09-30 A | 2004-11-05 |  | 85% | 4d? | 30d |  | start no earlier than 2004-09-30 |
| 74 | 8 | 1. Esittely | milestone | 0d | 2004-11-02 | 2004-11-02 |  |  |  | 34d |  | start no earlier than 2004-11-02 |
| 75 | 9 | Toteutus |  | 25d? | 2004-10-25 A | 2004-11-26 |  | 48% | 13d? | 15d |  | start no earlier than 2004-10-25 |
| 76 | 10 | Testattava prototyyppi valmis | milestone | 0d | 2004-11-15 | 2004-11-15 |  |  |  | 25d |  | start no earlier than 2004-11-15 |
| 77 | 11 | Testaus |  | 12d? | 2004-11-15 | 2004-11-30 |  |  |  | 13d |  | start no earlier than 2004-11-15 |
| 78 | 12 | 2. Esittely(ei sovittu)***********VIIKKO TIEDETÄÄN | milestone | 0d | 2004-12-01 | 2004-12-01 |  |  |  | 13d |  | start no earlier than 2004-12-01 |
| 79 | 13 | Sovelluksen viimeistely |  | 5d? | 2004-11-29 | 2004-12-03 |  |  |  | 10d |  | start no earlier than 2004-11-29 |
| 80 | 14 | Loppuesittely(ei sovittu)*************VIIKKO TIEDETÄÄN | milestone | 0d? | 2004-12-15 | 2004-12-15 |  |  |  | 3d |  | start no earlier than 2004-12-15 |
| 81 | 15 | Projektin viimeistely |  | 8d? | 2004-12-01 | 2004-12-10 |  |  |  | 5d | 0d | start no earlier than 2004-12-01 |
| 82 | 16 | Projektin viimeinen palaveri(ei sovittu)******** | milestone | 0d | 2004-12-13 | 2004-12-13 | 81 |  |  | 5d |  | start no earlier than 2004-12-13 |
| 83 | 1.3.17 | Projektin hallinta |  | 66d? | 2004-09-17 A | 2004-12-17 |  | 64% | 24d? | 0d |  |  |
